# Planning_LFR_PFM_21avril2015_v1

Schedule from MS Project, 2014-07-09 to 2015-11-25, 7 hours a day, A marks actual dates.
CNRS - LESIA

## Calendars

- Standard: Mon-Fri 09:00-12:00, 14:00-18:00; Sat-Sun off.

## Schedule

| ID | WBS | Task | Type | Duration | Start | Finish | Predecessors | Complete | Remaining | Baseline 1 start | Baseline 1 finish | Total slack | Free slack | Constraint | Text9 |
| --- | --- | --- | --- | --- | --- | --- | --- | --- | --- | --- | --- | --- | --- | --- | --- |
| 1 | 1 | **Hardware developments** |  | 361d | 2014-07-09 A | 2015-11-25 |  | 22% | 280.25d | 2014-04-07 | 2015-10-30 | 0d |  |  | LFR |
| 2 | 1.1 | **LFR FM HW design and development** |  | 361d | 2014-07-09 A | 2015-11-25 |  | 22% | 280.25d | 2014-07-09 | 2015-10-30 | 0d |  |  | LFR |
| 3 | 1.1.1 | H/W definition and schematics (update) |  | 10d | 2015-04-21 | 2015-05-04 |  |  |  | 2015-03-10 | 2015-03-30 | 0d |  |  | LFR |
| 4 | 1.1.2 | PCB layout |  | 10d | 2015-05-05 | 2015-05-18 | 3 |  |  | 2015-03-31 | 2015-04-13 | 0d |  |  | LFR |
| 5 | 1.1.3 | KP PCB layout |  | 1d | 2015-05-19 | 2015-05-19 | 4 |  |  | 2015-04-13 | 2015-04-13 | 136d |  |  | LFR |
| 6 | 1.1.4 | MRR preparation (documentation) |  | 5d | 2015-05-19 | 2015-05-25 | 4 |  |  | 2015-04-14 | 2015-04-14 | 132d |  |  | LFR |
| 7 | 1.1.5 | PCB manufacturing |  | 50d | 2015-05-19 | 2015-07-27 | 4 |  |  | 2015-04-14 | 2015-06-12 | 0d |  |  | LFR |
| 8 | 1.1.6 | TCS Parts procurement |  | 225.5d | 2014-07-09 A | 2015-05-20 |  | 39% | 138.6d | 2014-07-09 | 2015-05-28 | 50d | 0d | start no earlier than 2014-07-09 | LFR |
| 9 | 1.1.7 | LFR FM Parts available for assembly | milestone | 0d | 2015-05-20 | 2015-05-20 | 8 |  |  | 2015-05-28 | 2015-05-28 | 50d |  |  | LFR |
| 10 | 1.1.8 | **LFR FM HW design,dev & tests** |  | 87d | 2015-07-28 | 2015-11-25 |  |  |  | 2015-06-15 | 2015-10-30 | 0d |  |  | LFR |
| 11 | 1.1.8.1 | Board population |  | 20d | 2015-07-28 | 2015-08-24 | 7, 8, 9 |  |  | 2015-06-16 | 2015-07-29 | 0d |  |  | LFR |
| 12 | 1.1.8.2 | FPGA PROTO validation (at STEEL?) | milestone | 3d | 2015-08-25 | 2015-08-27 | 11 |  |  | 2015-07-30 | 2015-07-30 | 0d |  |  | LFR |
| 13 | 1.1.8.3 | FPGA FM programming | manual | 2d | 2015-08-28 | 2015-08-31 | 12 |  |  |  |  |  |  |  |  |
| 14 | 1.1.8.4 | FPGA FM validation (at STEEL?) | manual | 3d | 2015-09-01 | 2015-09-03 | 13 |  |  |  |  |  |  |  |  |
| 15 | 1.1.8.5 | FPGA soldering |  | 3d | 2015-09-04 | 2015-09-08 | 14 |  |  | 2015-07-31 | 2015-08-20 | 0d |  |  | LFR |
| 16 | 1.1.8.6 | Final validation by STEEL/LPP |  | 1d | 2015-09-09 | 2015-09-09 | 15 |  |  | 2015-08-21 | 2015-08-21 | 0d |  |  | LFR |
| 17 | 1.1.8.7 | TRR preparation (documentation) | milestone | 0d | 2015-09-09 | 2015-09-09 | 16 |  |  | 2015-08-21 | 2015-08-21 | 55d |  |  | LFR |
| 18 | 1.1.8.8 | Boards ready for TRR | milestone | 0d | 2015-09-09 | 2015-09-09 | 16 |  |  | 2015-08-21 | 2015-08-21 | 0d |  |  | LFR |
| 19 | 1.1.8.9 | TRR |  | 1.1d | 2015-09-10 | 2015-09-11 | 18 |  |  | 2015-08-24 | 2015-08-24 | 0d |  |  | LFR |
| 20 | 1.1.8.10 | Board full fonctionnal and performance tests |  | 11d | 2015-09-11 | 2015-09-28 | 19 |  |  | 2015-08-25 | 2015-09-07 | 0d |  |  | LFR |
| 21 | 1.1.8.11 | Calibration |  | 11d | 2015-09-28 | 2015-10-13 | 20 |  |  | 2015-09-08 | 2015-09-21 | 0d |  |  | LFR |
| 22 | 1.1.8.12 | Board EMC Tests |  | 5.5d | 2015-10-13 | 2015-10-20 | 21 |  |  | 2015-09-22 | 2015-09-28 | 0d |  |  | LFR |
| 23 | 1.1.8.13 | Board back to STEEL |  | 2.2d | 2015-10-20 | 2015-10-22 | 22 |  |  | 2015-09-29 | 2015-09-30 | 0d |  |  | LFR |
| 24 | 1.1.8.14 | MIP |  | 1.1d | 2015-10-22 | 2015-10-23 | 23 |  |  | 2015-10-01 | 2015-10-01 | 0d |  |  | LFR |
| 25 | 1.1.8.15 | Coating & Final mechanical integretion |  | 6.6d | 2015-10-23 | 2015-11-03 | 24 |  |  | 2015-10-02 | 2015-10-09 | 0d |  |  | LFR |
| 26 | 1.1.8.16 | Delivery to LPP |  | 1.1d | 2015-11-03 | 2015-11-04 | 25 |  |  | 2015-10-12 | 2015-10-12 | 0d |  |  | LFR |
| 27 | 1.1.8.17 | Post-coating tests and characterization |  | 5.5d | 2015-11-04 | 2015-11-12 | 26 |  |  | 2015-10-13 | 2015-10-19 | 0d |  |  | LFR |
| 28 | 1.1.8.18 | Final delivery to LPP | milestone | 0d | 2015-11-12 | 2015-11-12 | 27 |  |  | 2015-10-19 | 2015-10-19 | 0d |  |  | LFR |
| 29 | 1.1.8.19 | Board thermal tests (if any) |  | 3.3d | 2015-11-12 | 2015-11-17 | 28 |  |  | 2015-10-20 | 2015-10-22 | 0d |  |  | LFR |
| 30 | 1.1.8.20 | TRB/DRB preparation (datapackage) |  | 5.5d | 2015-11-17 | 2015-11-24 | 29 |  |  | 2015-10-23 | 2015-10-29 | 0d |  |  | LFR |
| 31 | 1.1.8.21 | TRB and DRB |  | 1.1d | 2015-11-24 | 2015-11-25 | 30 |  |  | 2015-10-30 | 2015-10-30 | 0d |  |  | LFR |
| 32 | 1.1.8.22 | LFR FM ready for delivery to lesia for AIT MEB | milestone | 0d | 2015-11-25 | 2015-11-25 | 31 |  |  | 2015-10-30 | 2015-10-30 | 0d |  |  | LFR |

Notes:
- 1: Text26: NC Hardware developments / Text30: 29/10/15 Hardware developments
- 2: Text26: NC FM HW design and development / Text30: 29/10/15 LFR FM HW design and development
- 3: Text26: NC H/W definition and schematics (update) / Text30: 21/01/11 H/W definition and schematics (update)
- 4: Text26: NC PCB layout / Text30: 07/04/15 PCB layout
- 5: Text26: NC KP PCB layout / Text30: 07/04/15 KP PCB layout
- 6: Text26: NC MRR preparation (documentation) / Text30: 08/04/15 MRR preparation (documentation)
- 7: Text26: NC PCB manufacturing / Text30: 08/06/15 PCB manufacturing
- 8: Text26: NC TCS Parts procurement / Text30: 28/05/15 TCS Parts procurement
- 9: Text26: NC LFR FM Parts available for assembly / Text30: 28/05/15 LFR FM Parts available for assembly
- 10: Text26: NC LFR FM HW assembly & tests / Text30: 29/10/15 LFR FM HW design,dev & tests
- 11: Text26: NC Parts assembly and Integration in mechanical frame / Text30: 28/07/15 Parts assembly and Integration in mechanical frame
- 12: Text26: NC LFR FM FPGA validation in the dedicated socket (at STEEL) / Text30: 29/07/15 LFR FM FPGA validation in the dedicated socket (at STEEL)
- 15: Text26: NC FPGA soldering / Text30: 19/08/15 FPGA soldering
- 16: Text26: NC Final validation by STEEL/LPP / Text30: 20/08/15 Final validation by STEEL/LPP
- 17: Text26: NC TRR preparation (documentation) / Text30: 20/08/15 TRR preparation (documentation)
- 18: Text26: NC Boards ready for TRR / Text30: 20/08/15 Boards ready for TRR
- 19: Text26: NC TRR / Text30: 21/08/15 TRR
- 20: Text26: NC Board full fonctionnal and performance tests / Text30: 04/09/15 Board full fonctionnal and performance tests
- 21: Text26: NC Calibration / Text30: 18/09/15 Calibration
- 22: Text26: NC Board EMC Tests / Text30: 25/09/15 Board EMC Tests
- 23: Text26: NC Board back to STEEL / Text30: 29/09/15 Board back to STEEL
- 24: Text26: NC MIP / Text30: 30/09/15 MIP
- 25: Text26: NC Coating & Final mechanical integretion / Text30: 08/10/15 Coating & Final mechanical integretion
- 26: Text26: NC Delivery to LPP / Text30: 09/10/15 Delivery to LPP
- 27: Text26: NC Post-coating tests and characterization / Text30: 16/10/15 Post-coating tests and characterization
- 28: Text26: NC Final delivery to LPP / Text30: 16/10/15 Final delivery to LPP
- 29: Text26: NC Board thermal tests (if any) / Text30: 21/10/15 Board thermal tests (if any)
- 30: Text26: NC TRB/DRB preparation (datapackage) / Text30: 28/10/15 TRB/DRB preparation (datapackage)
- 31: Text26: NC TRB and DRB / Text30: 29/10/15 TRB and DRB
- 32: Text26: NC LFR FM ready for delivery to lesia for AIT MEB / Text30: 29/10/15 LFR FM ready for delivery to lesia for AIT MEB

| ID | WBS | Task | Type | Duration | Start | Finish | Predecessors | Complete | Remaining | Baseline 1 start | Baseline 1 finish | Total slack | Free slack | Constraint | Text9 | Text1 | Text26 |
| --- | --- | --- | --- | --- | --- | --- | --- | --- | --- | --- | --- | --- | --- | --- | --- | --- | --- |
| 33 | 2 | **LFR FPGA developments** |  | 247d | 2014-07-25 A | 2015-07-06 |  | 45% | 135.41d | 2014-07-25 | 2015-04-07 | 102d |  |  | LFR |  |  |
| 34 | 2.1 | **EQM firmware** |  | 112.3d | 2014-07-25 A | 2014-12-30 |  | 72% | 31.53d | 2014-07-25 | 2014-12-19 | 236.7d |  |  | LFR |  |  |
| 35 | 2.1.1 | VHDL: waveform picker refinement |  | 91.3d | 2014-08-25 A | 2014-12-30 |  | 78% | 19.8d | 2014-08-25 | 2014-12-18 | 236.7d |  | start no earlier than 2014-08-25 | LFR | A confirmer | NC VHDL: waveform picker refinement |
| 36 | 2.1.2 | **flight RAM evaluation board** |  | 39.5d | 2014-07-25 A | 2014-09-18 |  | 47% | 20.79d | 2014-07-25 | 2014-09-17 | 309.5d |  |  | LFR |  |  |
| 37 | 2.1.2.1 | PCB design and manufacturing |  | 22d | 2014-07-25 | 2014-08-25 |  |  |  | 2014-07-25 | 2014-08-22 | 327d |  | start no earlier than 2014-07-25 | LFR | A confirmer | NC PCB design and manufacturing |
| 38 | 2.1.2.2 | flight RAM bending and cutting |  | 14.3d | 2014-08-25 A | 2014-09-12 A |  | 100% |  | 2014-08-25 | 2014-09-10 |  |  | start no earlier than 2014-08-25 | LFR |  | NC flight RAM bending and cutting |
| 39 | 2.1.2.3 | Board population |  | 5.5d | 2014-09-11 A | 2014-09-18 A | 37, 38 | 100% |  | 2014-09-11 | 2014-09-17 |  |  |  | LFR |  | NC Board population |
| 40 | 2.1.3 | VHDL: flight RAM memory controler |  | 72.6d | 2014-09-18 A | 2014-12-29 | 39 | 71% | 20.9d | 2014-09-18 | 2014-12-19 | 237.4d |  |  | LFR | A confirmer | NC VHDL: flight RAM memory controler |
| 41 | 2.1.4 | Documentation |  | 17.6d | 2014-09-15 A | 2014-10-08 A | 35 | 100% |  | 2014-09-15 | 2014-10-06 |  |  | start no earlier than 2012-01-05 | LFR |  | NC Documentation |
| 42 | 2.2 | **FM firmware** |  | 196d | 2014-10-06 A | 2015-07-06 |  | 17% | 163.16d | 2014-10-06 | 2015-04-07 | 102d |  |  | LFR |  |  |
| 43 | 2.2.1 | VHDL: downsampling filter, all frequencies |  | 66d | 2014-10-06 A | 2015-01-05 |  | 53% | 30.8d | 2014-10-06 | 2015-01-12 | 164.9d | 0d |  | LFR | A confirmer | NC VHDL: downsampling filter, all frequencies |
| 44 | 2.2.2 | VHDL: SCM calibration |  | 22d | 2015-01-06 | 2015-02-04 | 43 |  |  | 2015-01-13 | 2015-02-09 | 210d |  |  | LFR | A confirmer | NC VHDL: SCM calibration |
| 45 | 2.2.3 | VHDL: housekeeping |  | 22d | 2015-01-06 | 2015-02-04 | 43 |  |  | 2015-01-13 | 2015-02-09 | 164.9d | 0d |  | LFR | A confirmer | NC VHDL: housekeeping |
| 46 | 2.2.4 | Completion of the firmware and tests documentation |  | 22d | 2015-02-05 | 2015-03-06 | 45 |  |  | 2015-02-10 | 2015-03-09 | 164.9d | 0d |  | LFR | A confirmer | NC Completion of the firmware and tests documentation |
| 47 | 2.2.5 | Tests result analysis (Cnes / Lesia) |  | 5.5d | 2015-03-09 | 2015-03-16 | 46 |  |  | 2015-03-10 | 2015-03-16 | 164.9d | 0d |  | LFR | A confirmer | NC Tests result analysis (Cnes / Lesia) |
| 48 | 2.2.6 | Validation KP |  | 1.1d | 2015-03-16 | 2015-03-17 | 47 |  |  | 2015-03-17 | 2015-03-17 | 164.9d | 0d |  | LFR |  | NC Validation KP |
| 49 | 2.2.7 | Complementary tests follow-up analysis |  | 5.5d | 2015-03-17 | 2015-03-25 | 48 |  |  | 2015-03-18 | 2015-03-24 | 164.9d | 0d |  | LFR |  | NC Complementary tests follow-up analysis |
| 50 | 2.2.8 | GO / NOGO FM FPGA ready for programmation | milestone | 0d | 2015-03-25 | 2015-03-25 | 49 |  |  | 2015-03-24 | 2015-03-24 | 164.9d | 0d |  | LFR |  | NC GO / NOGO FM FPGA ready for programmation |
| 51 | 2.2.9 | **PPBI** |  | 73.9d | 2015-03-25 | 2015-07-06 |  |  |  | 2015-01-14 | 2015-04-07 | 102d |  |  | LFR |  |  |
| 52 | 2.2.9.1 | PPBI: NRE |  | 55d | 2015-04-21 | 2015-07-06 | 50FF |  |  | 2015-01-14 | 2015-03-24 | 102d |  |  | LFR | A confirmer | NC PPBI: NRE |
| 53 | 2.2.9.2 | FPGA programmation |  | 1.1d | 2015-03-25 | 2015-03-26 | 50 |  |  | 2015-03-25 | 2015-03-25 | 164.9d | 0d |  | LFR |  | NC FPGA programmation |
| 54 | 2.2.9.3 | PPBI: electrical tests |  | 9.9d | 2015-03-26 | 2015-04-09 | 53 |  |  | 2015-03-26 | 2015-04-07 | 164.9d | 0d |  | LFR |  | NC PPBI: electrical tests |
| 55 | 2.2.10 | Firmware ready for FM assembly | milestone | 0d | 2015-04-09 | 2015-04-09 | 54 |  |  | 2015-04-07 | 2015-04-07 | 164.9d |  |  | LFR |  | NC Firmware ready for FM assembly |
| 56 | 3 | **Onboard analyser SW developments** |  | 255.2d | 2014-10-01 | 2015-09-23 |  |  |  | 2014-10-01 | 2015-09-02 | 45.8d |  |  | LFR |  |  |
| 57 | 3.1 | R2 DRB/CDR |  | 2.2d | 2014-10-01 | 2014-10-03 |  |  |  | 2014-10-01 | 2014-10-02 | 45.8d | 0d | start no earlier than 2014-10-01 | LFR | A confirmer | NC R2 DRB/CDR |
| 58 | 3.2 | R3 software |  | 253d | 2014-10-03 | 2015-09-23 | 57 |  |  | 2014-10-03 | 2015-09-02 | 45.8d |  |  | LFR | A confirmer | NC R3 software |

Notes:
- 33: Text30: 07/04/15 LFR FPGA developments
- 34: Text30: 19/12/14 EM2 firmware
- 35: A vérifier / Text30: 18/12/14 VHDL: waveform picker refinement
- 36: Text30: 17/09/14 flight RAM evaluation board
- 37: Text30: 22/08/14 PCB design and manufacturing
- 38: Text30: 10/09/14 flight RAM bending and cutting
- 39: Text30: 17/09/14 Board population
- 40: Text30: 19/12/14 VHDL: flight RAM memory controler
- 41: Text30: 06/10/14 Documentation
- 42: Text30: 07/04/15 FM firmware
- 43: Text30: 12/01/15 VHDL: downsampling filter, all frequencies
- 44: Text30: 09/02/15 VHDL: SCM calibration
- 45: Text30: 09/02/15 VHDL: housekeeping
- 46: Text30: 09/03/15 Completion of the firmware and tests documentation
- 47: Text30: 16/03/15 Tests result analysis (Cnes / Lesia)
- 48: Text30: 17/03/15 Validation KP
- 49: Text30: 24/03/15 Complementary tests follow-up analysis
- 50: Text30: 24/03/15 GO / NOGO FM FPGA ready for programmation
- 51: Text30: 07/04/15 PPBI
- 52: Text30: 24/03/15 PPBI: NRE
- 53: Text30: 25/03/15 FPGA programmation
- 54: Text30: 07/04/15 PPBI: electrical tests
- 55: Text30: 07/04/15 Firmware ready for FM assembly
- 56: Text30: 02/09/15 Onboard analyser SW developments
- 57: Text30: 02/10/14 R2 DRB/CDR
- 58: Text30: 02/09/15 R3 software
